# QC Proposal estimates

Schedule from MS Project, 2001-10-12 to 2002-01-17.

## Calendars

- Standard: Mon-Fri 08:00-12:00, 13:00-17:00; Sat-Sun off.

## Resources

| Resource |
| --- |
| WA |
| EM |
| JM/EM |
| JM |
| TBD |

## Schedule

| ID | WBS | Task | Duration | Start | Finish | Predecessors | Total slack | Free slack | Constraint | Resources | Work |
| --- | --- | --- | --- | --- | --- | --- | --- | --- | --- | --- | --- |
| 1 | 1 | **Phase II** | 46d | 2001-11-15 | 2002-01-17 |  | 0d |  | start no earlier than 2001-11-15 |  | 1048h |
| 3 | 1.1 | Monitoring engine for acquired data | 5d | 2001-11-15 | 2001-11-21 |  | 4d | 0d |  | WA | 40h |
| 4 | 1.2 | Command and control protocol and framework | 2d | 2001-11-22 | 2001-11-23 | 3 | 4d | 0d |  | WA | 16h |
| 5 | 1.3 | Review of test data suitability | 5d | 2001-11-15 | 2001-11-21 |  | 0d |  |  | EM | 40h |
| 7 | 1.4 | **System Monitoring** | 13d | 2001-11-26 | 2001-12-12 |  | 4d |  |  |  | 104h |
| 8 | 1.4.1 | Identify candidate metrics | 1d | 2001-11-26 | 2001-11-26 | 4 | 4d | 0d |  | WA | 8h |
| 9 | 1.4.2 | Metrics calculations and transmission | 10d | 2001-11-27 | 2001-12-10 | 8 | 4d | 0d |  | WA | 80h |
| 10 | 1.4.3 | Algorithm validation | 2d | 2001-12-11 | 2001-12-12 | 9 | 4d | 0d |  | WA | 16h |
| 12 | 1.5 | **Data Quality Monitoring** | 46d | 2001-11-15 | 2002-01-17 |  | 0d |  |  |  | 768h |
| 14 | 1.5.1 | **Side Scan Sonar** | 37d | 2001-11-15 | 2002-01-04 |  | 0d |  |  |  | 544h |
| 15 | 1.5.1.1 | Bottom detection algorithm | 10d | 2001-11-15 | 2001-11-28 |  | 0d |  |  | JM | 80h |
| 16 | 1.5.1.2 | Computation engine (stacking, energy calculations etc) | 10d | 2001-12-13 | 2001-12-26 | 10 | 4d | 0d |  | WA | 80h |
| 17 | 1.5.1.3 | Pixel and ping down-sampler | 2d | 2001-12-27 | 2001-12-28 | 16 | 4d | 0d |  | WA | 16h |
| 18 | 1.5.1.4 | Algorithm evaluation | 5d | 2001-12-31 | 2002-01-04 | 17 | 4d | 0d |  | WA | 40h |
| 20 | 1.5.1.5 | **Wavelet Compression** | 26d | 2001-11-22 | 2001-12-27 |  | 0d |  |  |  | 328h |
| 21 | 1.5.1.5.1 | Study candidate mother wavelets | 20d | 2001-11-22 | 2001-12-19 | 5 | 0d |  |  | EM | 160h |
| 22 | 1.5.1.5.2 | Wavelet transform implementation | 5d | 2001-11-29 | 2001-12-05 | 15 | 0d |  |  | JM | 40h |
| 23 | 1.5.1.5.3 | Adaptive Huffman coding scheme | 5d | 2001-12-06 | 2001-12-12 | 22 | 0d |  |  | JM | 40h |
| 24 | 1.5.1.5.4 | Dynamic wavelet selection | 5d | 2001-12-13 | 2001-12-19 | 23 | 0d |  |  | JM | 40h |
| 25 | 1.5.1.5.5 | Evaluate performance against real sample data | 5d | 2001-12-20 | 2001-12-26 | 21, 24 | 0d |  |  | EM | 40h |
| 26 | 1.5.1.5.6 | Compresed imagery transmission | 1d | 2001-12-27 | 2001-12-27 | 24, 25 | 8d | 0d |  | JM | 8h |
| 28 | 1.5.2 | **Sub-bottom Profiler** | 4d | 2001-12-27 | 2002-01-01 |  | 0d |  |  |  | 48h |
| 30 | 1.5.2.1 | **Wavelet Compression** | 4d | 2001-12-27 | 2002-01-01 |  | 0d |  |  |  | 48h |
| 31 | 1.5.2.1.1 | Design and select suitable mother wavlets | 2d | 2001-12-27 | 2001-12-28 | 25 | 0d |  |  | EM | 16h |
| 32 | 1.5.2.1.2 | Modify dynamic wavelet selection criteria | 2d | 2001-12-28 | 2001-12-31 | 26 | 8d | 0d |  | JM | 16h |
| 33 | 1.5.2.1.3 | Algorithm performance analysis | 2d | 2001-12-31 | 2002-01-01 | 31 | 0d |  |  | EM | 16h |

| ID | WBS | Task | Type | Duration | Start | Finish | Predecessors | Total slack | Free slack | Resources | Work |
| --- | --- | --- | --- | --- | --- | --- | --- | --- | --- | --- | --- |
| 35 | 1.5.3 | **Bathymetry** |  | 13d | 2002-01-01 | 2002-01-17 |  | 0d |  |  | 176h |
| 36 | 1.5.3.1 | QC flag review and enhancment |  | 10d | 2002-01-02 | 2002-01-15 | 33 | 0d |  | EM | 80h |
| 37 | 1.5.3.2 | QC flag metric calculations |  | 5d | 2002-01-07 | 2002-01-11 | 18 | 4d |  | WA | 40h |
| 38 | 1.5.3.3 | Top-side multi-layer representation on plan display |  | 5d | 2002-01-01 | 2002-01-07 | 32 | 8d |  | JM | 40h |
| 39 | 1.5.3.4 | Testing |  | 2d | 2002-01-16 | 2002-01-17 | 36 | 0d |  | EM | 16h |
| 41 | 1.6 | **Miscellaneous** |  | 10d | 2001-12-31 | 2002-01-11 |  | 4d |  |  | 80h |
| 42 | 1.6.1 | Documentation |  | 10d | 2001-12-31 | 2002-01-11 | 9, 17, 25 | 4d |  | TBD | 80h |
| 44 | 2 | End Phase II | milestone | 0d | 2002-01-17 | 2002-01-17 | 39, 42, 18, 10 | 0d |  |  |  |
| 46 | 3 | **Phase III** |  | 54d | 2001-10-12 | 2001-12-26 |  | 16d |  |  | 832h |
| 48 | 3.1 | **Data Quality Monitoring** |  | 54d | 2001-10-12 | 2001-12-26 |  | 16d |  |  | 808h |
| 50 | 3.1.1 | **Side Scan Sonar** |  | 32d | 2001-10-12 | 2001-11-26 |  | 16d |  |  | 400h |
| 51 | 3.1.1.1 | Alarm trigger parameter mechanism and protocol |  | 2d | 2001-10-12 | 2001-10-15 |  | 33d | 0d | WA | 16h |
| 53 | 3.1.1.2 | **Multi-modal Statistical Model** |  | 32d | 2001-10-12 | 2001-11-26 |  | 16d |  |  | 384h |
| 54 | 3.1.1.2.1 | Analysis of sample data |  | 10d | 2001-10-12 | 2001-10-25 |  | 16d | 0d | EM | 80h |
| 55 | 3.1.1.2.2 | Design of statistical distribution |  | 3d | 2001-10-26 | 2001-10-30 | 54 | 16d | 0d | EM | 24h |
| 56 | 3.1.1.2.3 | PDF comparision engine |  | 10d | 2001-10-16 | 2001-10-29 | 51 | 33d | 0d | WA | 80h |
| 57 | 3.1.1.2.4 | Statistical parameter determination |  | 5d | 2001-10-31 | 2001-11-06 | 55 | 16d | 0d | EM | 40h |
| 58 | 3.1.1.2.5 | Auto-calibration tool |  | 20d | 2001-10-30 | 2001-11-26 | 56 | 33d | 0d | WA | 160h |
| 60 | 3.1.2 | **Sub-bottom Profiler** |  | 28d | 2001-10-12 | 2001-11-20 |  | 34d |  |  | 160h |
| 62 | 3.1.2.1 | **Multi-modal Statistical Model** |  | 28d | 2001-10-12 | 2001-11-20 |  | 34d |  |  | 160h |
| 63 | 3.1.2.1.1 | Analysis of sample data |  | 5d | 2001-11-07 | 2001-11-13 | 57 | 16d | 0d | EM | 40h |
| 64 | 3.1.2.1.2 | Design of statistical distribution |  | 5d | 2001-11-14 | 2001-11-20 | 63 | 16d | 0d | EM | 40h |
| 65 | 3.1.2.1.3 | Modify auto-calibration tool |  | 10d | 2001-10-12 | 2001-10-25 |  | 60d |  | JM | 80h |
| 67 | 3.1.3 | **Bathymetry** |  | 26d | 2001-11-21 | 2001-12-26 |  | 16d |  |  | 248h |
| 68 | 3.1.3.1 | Study and identify known invalid parameter setup scenarios |  | 5d | 2001-11-21 | 2001-11-27 | 64 | 16d | 0d | EM | 40h |
| 69 | 3.1.3.2 | Identify mission critical candidate parameters and sensible default ranges |  | 6d | 2001-11-28 | 2001-12-05 | 68 | 16d | 0d | EM | 48h |
| 70 | 3.1.3.3 | Design and implement Fuzzy rule-based expert system to monitor parameters |  | 15d | 2001-12-06 | 2001-12-26 | 69 | 16d |  | EM | 120h |
| 71 | 3.1.3.4 | Knowledge exchange tool to train system |  | 5d | 2001-11-27 | 2001-12-03 | 58 | 33d |  | WA | 40h |

| ID | WBS | Task | Type | Duration | Start | Finish | Predecessors | Total slack | Free slack | Resources | Work |
| --- | --- | --- | --- | --- | --- | --- | --- | --- | --- | --- | --- |
| 73 | 3.2 | **Miscellaneous** |  | 3d | 2001-10-12 | 2001-10-16 |  | 67d |  |  | 24h |
| 74 | 3.2.1 | Documentation |  | 3d | 2001-10-12 | 2001-10-16 |  | 67d |  | TBD | 24h |
| 76 | 4 | End Phase III | milestone | 0d | 2001-10-12 | 2001-10-12 |  | 54d |  |  |  |
| 78 | 5 | **Phase IV** |  | 35d | 2001-10-12 | 2001-11-29 |  | 35d |  |  | 544h |
| 79 | 5.1 | **Data Quality Monitoring** |  | 35d | 2001-10-12 | 2001-11-29 |  | 35d |  |  | 520h |
| 81 | 5.1.1 | **Side Scan Sonar** |  | 30d | 2001-10-12 | 2001-11-22 |  | 35d |  |  | 240h |
| 82 | 5.1.1.1 | Object detection |  | 20d | 2001-10-12 | 2001-11-08 |  | 19d | 0d | WA | 160h |
| 83 | 5.1.1.2 | Texture analysis |  | 10d | 2001-11-09 | 2001-11-22 | 82 | 19d | 0d | WA | 80h |
| 85 | 5.1.2 | **Bathymetry** |  | 35d | 2001-10-12 | 2001-11-29 |  | 35d |  |  | 280h |
| 87 | 5.1.2.1 | **Digital Terrain Model** |  | 35d | 2001-10-12 | 2001-11-29 |  | 35d |  |  | 280h |
| 88 | 5.1.2.1.1 | Develop model for on-the-fly analysis |  | 20d | 2001-10-12 | 2001-11-08 |  | 24d | 0d | EM | 160h |
| 89 | 5.1.2.1.2 | Correlate DTM model with texture analysis |  | 5d | 2001-11-09 | 2001-11-15 | 88 | 24d | 0d | EM | 40h |
| 90 | 5.1.2.1.3 | Validate model against real data sets of opportunity |  | 5d | 2001-11-16 | 2001-11-22 | 89 | 24d |  | EM | 40h |
| 91 | 5.1.2.1.4 | Compute statistical descriptors and transmit |  | 5d | 2001-11-23 | 2001-11-29 | 83 | 19d |  | WA | 40h |
| 93 | 5.2 | **Miscellaneous** |  | 3d | 2001-10-12 | 2001-10-16 |  | 67d |  |  | 24h |
| 94 | 5.2.1 | Documentation |  | 3d | 2001-10-12 | 2001-10-16 |  | 51d |  | TBD | 24h |
| 96 | 6 | End Phase IV | milestone | 0d | 2001-10-12 | 2001-10-12 |  | 54d |  |  |  |
