# Project Schedule Phase 1 and 2

Schedule from MS Project, 2001-07-31 to 2001-09-12.

## Calendars

- Standard: Mon-Fri 08:00-12:00, 13:00-17:00; Sat-Sun off.

## Resources

| Resource |
| --- |
| WA |
| JM |
| WA/JM |
| TBD |
| End of Phase I |

## Schedule

| ID | WBS | Task | Duration | Start | Finish | Predecessors | Total slack | Constraint | Resources | Work |
| --- | --- | --- | --- | --- | --- | --- | --- | --- | --- | --- |
| 1 | 1 | **PHASE I** | 31.38d | 2001-07-31 08:00 | 2001-09-12 11:00 |  | 0d | start no earlier than 2001-07-31 08:00 |  | 405h |
| 3 | 1.1 | **Wet End** | 25.38d | 2001-07-31 08:00 | 2001-09-04 11:00 |  | 0d |  |  | 203h |
| 5 | 1.1.1 | **General** | 2.38d | 2001-07-31 08:00 | 2001-08-02 11:00 |  | 0d |  |  | 19h |
| 7 | 1.1.1.1 | General re-structure (polled acquisition cycle etc). | 8h | 2001-07-31 08:00 | 2001-07-31 17:00 |  | 0d |  | WA | 8h |
| 8 | 1.1.1.2 | Socket support classes. | 4h | 2001-08-01 08:00 | 2001-08-01 12:00 | 7 | 0d |  | WA | 4h |
| 9 | 1.1.1.3 | Integrate new sensor list (DLL registration). | 1h | 2001-08-01 13:00 | 2001-08-01 14:00 | 8 | 0d |  | WA | 1h |
| 10 | 1.1.1.4 | Hi-Res timing support class(es). | 4h | 2001-08-01 14:00 | 2001-08-02 09:00 | 9 | 0d |  | WA | 4h |
| 11 | 1.1.1.5 | Testing | 2h | 2001-08-02 09:00 | 2001-08-02 11:00 | 10 | 0d |  | WA | 2h |
| 13 | 1.1.2 | **EdgeTech Integration** | 6.25d | 2001-08-02 11:00 | 2001-08-10 14:00 | 5 | 0d |  |  | 50h |
| 15 | 1.1.2.1 | Create DLL and framework. | 2h | 2001-08-02 11:00 | 2001-08-02 14:00 | 11 | 0d |  | WA | 2h |
| 16 | 1.1.2.2 | Command and cotrol framework. | 4h | 2001-08-02 14:00 | 2001-08-03 09:00 | 15 | 0d |  | WA | 4h |
| 17 | 1.1.2.3 | Data collection framework. | 8h | 2001-08-03 09:00 | 2001-08-06 09:00 | 16 | 0d |  | WA | 8h |
| 18 | 1.1.2.4 | Message handler. | 8h | 2001-08-06 09:00 | 2001-08-07 09:00 | 17 | 0d |  | WA | 8h |
| 19 | 1.1.2.5 | Ping/channel sequencer. | 8h | 2001-08-07 09:00 | 2001-08-08 09:00 | 18 | 0d |  | WA | 8h |
| 20 | 1.1.2.6 | Sonar configuration save / restore settings. | 8h | 2001-08-08 09:00 | 2001-08-09 09:00 | 19 | 0d |  | WA | 8h |
| 21 | 1.1.2.7 | Sonar command set for remote and startup control. | 4h | 2001-08-09 09:00 | 2001-08-09 14:00 | 20 | 0d |  | WA | 4h |
| 22 | 1.1.2.8 | Synchronize FS-AS and payload controller clocks. | 4h | 2001-08-09 14:00 | 2001-08-10 09:00 | 21 | 0d |  | WA | 4h |
| 23 | 1.1.2.9 | Testing. | 4h | 2001-08-10 09:00 | 2001-08-10 14:00 | 22 | 0d |  | WA | 4h |
| 25 | 1.1.3 | **Logging** | 6d | 2001-08-10 14:00 | 2001-08-20 14:00 | 13 | 0d |  |  | 48h |
| 27 | 1.1.3.1 | Record sequencing and logging support class(es). | 4h | 2001-08-10 14:00 | 2001-08-13 09:00 | 23 | 0d |  | WA | 4h |
| 28 | 1.1.3.2 | 7k compatible logging API (protocol and disk I/O). | 32h | 2001-08-13 09:00 | 2001-08-17 09:00 | 27 | 0d |  | WA | 32h |
| 29 | 1.1.3.3 | Auto change of file names on file size and named logging based on time. | 2h | 2001-08-17 09:00 | 2001-08-17 11:00 | 28 | 0d |  | WA | 2h |
| 30 | 1.1.3.4 | Define and implement records for: EdgeTech SSS and SBP, controller commands and vehicle atitude, position and heading | 4h | 2001-08-17 11:00 | 2001-08-17 16:00 | 29 | 0d |  | WA | 4h |
| 31 | 1.1.3.5 | Defined reserved id range for QC records (Phase II requirement). | 1h | 2001-08-17 16:00 | 2001-08-17 17:00 | 30 | 0d |  | WA | 1h |
| 32 | 1.1.3.6 | Periodically flush logging buffers (minimize potential data loss in event of system crash). | 1h | 2001-08-20 08:00 | 2001-08-20 09:00 | 31 | 0d |  | WA | 1h |
| 33 | 1.1.3.7 | Testing | 4h | 2001-08-20 09:00 | 2001-08-20 14:00 | 32 | 0d |  | WA | 4h |

| ID | WBS | Task | Duration | Start | Finish | Predecessors | Total slack | Free slack | Resources | Work |
| --- | --- | --- | --- | --- | --- | --- | --- | --- | --- | --- |
| 35 | 1.1.4 | **Payload Controller** | 9.25d | 2001-08-20 14:00 | 2001-08-31 16:00 | 25 | 0d |  |  | 74h |
| 37 | 1.1.4.1 | Expand saved and restored parameter list (includes sensor state). | 2h | 2001-08-20 14:00 | 2001-08-20 16:00 | 33 | 0d |  | WA | 2h |
| 38 | 1.1.4.2 | Alarm relays ??? | 16h | 2001-08-20 16:00 | 2001-08-22 16:00 | 37 | 0d |  | WA | 16h |
| 39 | 1.1.4.3 | Sonar trigger pulse controller | 16h | 2001-08-22 16:00 | 2001-08-24 16:00 | 38 | 0d |  | WA | 16h |
| 40 | 1.1.4.4 | 1PPS input controller for time sync | 16h | 2001-08-24 16:00 | 2001-08-28 16:00 | 39 | 0d |  | WA | 16h |
| 41 | 1.1.4.5 | UTC time synchronization. | 4h | 2001-08-28 16:00 | 2001-08-29 11:00 | 40 | 0d |  | WA | 4h |
| 42 | 1.1.4.6 | Supervise new sensors. | 8h | 2001-08-29 11:00 | 2001-08-30 11:00 | 41 | 0d |  | WA | 8h |
| 43 | 1.1.4.7 | Event log of commands recieved. | 4h | 2001-08-30 11:00 | 2001-08-30 16:00 | 42 | 0d |  | WA | 4h |
| 44 | 1.1.4.8 | Define and expand command set. | 4h | 2001-08-30 16:00 | 2001-08-31 11:00 | 43 | 0d |  | WA | 4h |
| 45 | 1.1.4.9 | Testing | 4h | 2001-08-31 11:00 | 2001-08-31 16:00 | 44 | 0d |  | WA | 4h |
| 47 | 1.1.5 | **Vehicle Parameters** | 0.75d | 2001-08-31 16:00 | 2001-09-03 14:00 | 35 | 0d |  |  | 6h |
| 49 | 1.1.5.1 | Create DLL and framework for reciept of heading, attitude and position input. | 4h | 2001-08-31 16:00 | 2001-09-03 11:00 | 45 | 0d |  | WA | 4h |
| 50 | 1.1.5.2 | Testing. | 2h | 2001-09-03 11:00 | 2001-09-03 14:00 | 49 | 0d |  | WA | 2h |
| 52 | 1.1.6 | **Miscellaneous** | 0.75d | 2001-09-03 14:00 | 2001-09-04 11:00 | 47 | 0d |  |  | 6h |
| 54 | 1.1.6.1 | Transmit status and summary information (including logging statistics). | 4h | 2001-09-03 14:00 | 2001-09-04 09:00 | 50 | 0d |  | WA | 4h |
| 55 | 1.1.6.2 | Per channel emulation support (I.e., test patterns). | 2h | 2001-09-04 09:00 | 2001-09-04 11:00 | 54 | 0d |  | WA | 2h |
| 57 | 1.2 | **Dry End** | 19.25d | 2001-07-31 08:00 | 2001-08-27 10:00 |  | 7.5d |  |  | 154h |
| 59 | 1.2.1 | **General** | 2.5d | 2001-07-31 08:00 | 2001-08-02 12:00 |  | 5.5d | 0d |  | 20h |
| 61 | 1.2.1.1 | Per sensor setup and control page | 16h | 2001-07-31 08:00 | 2001-08-01 17:00 |  | 5.5d | 0d | JM | 16h |
| 62 | 1.2.1.2 | Extened command set support | 4h | 2001-08-02 08:00 | 2001-08-02 12:00 | 61 | 5.5d | 0d | JM | 4h |
| 64 | 1.2.2 | **GUI's for data viewing (Tethered mode or offline viewer (file replay)).** | 11.5d | 2001-08-02 13:00 | 2001-08-17 17:00 | 59 | 5.5d | 0d |  | 92h |
| 66 | 1.2.2.1 | Infrustructure for file or socket replay of 7k records (code re-use from wet end). | 8h | 2001-08-02 13:00 | 2001-08-03 12:00 | 62 | 5.5d | 0d | JM | 8h |
| 67 | 1.2.2.2 | Generic waterfall display. | 32h | 2001-08-03 13:00 | 2001-08-09 12:00 | 66 | 5.5d | 0d | JM | 32h |
| 68 | 1.2.2.3 | Waterfall (2 channel vertical) for SSS data. | 4h | 2001-08-09 13:00 | 2001-08-09 17:00 | 67 | 5.5d | 0d | JM | 4h |
| 69 | 1.2.2.4 | Waterfall (1 channel horizontal) for SBP data | 4h | 2001-08-10 08:00 | 2001-08-10 12:00 | 68 | 5.5d | 0d | JM | 4h |
| 70 | 1.2.2.5 | Generic time series plot graphic | 16h | 2001-08-10 13:00 | 2001-08-14 12:00 | 69 | 5.5d | 0d | JM | 16h |
| 71 | 1.2.2.6 | Time series plot for altitude and heading | 4h | 2001-08-14 13:00 | 2001-08-14 17:00 | 70 | 5.5d | 0d | JM | 4h |
| 72 | 1.2.2.7 | 2 x 1D timeseries plots for position | 16h | 2001-08-15 08:00 | 2001-08-16 17:00 | 71 | 5.5d | 0d | JM | 16h |
| 73 | 1.2.2.8 | Summary display for ping / time data | 8h | 2001-08-17 08:00 | 2001-08-17 17:00 | 72 | 5.5d | 0d | JM | 8h |

| ID | WBS | Task | Type | Duration | Start | Finish | Predecessors | Total slack | Free slack | Resources | Work |
| --- | --- | --- | --- | --- | --- | --- | --- | --- | --- | --- | --- |
| 75 | 1.2.3 | **GUIs for payload controller** |  | 5.25d | 2001-08-20 08:00 | 2001-08-27 10:00 | 64 | 7.5d |  |  | 42h |
| 77 | 1.2.3.1 | Setup, control and status review of sensors (sensor specific). |  | 16h | 2001-08-20 08:00 | 2001-08-21 17:00 | 73 | 5.5d | 0d | JM | 16h |
| 78 | 1.2.3.2 | GUI for setup and synchronization scheme. |  | 16h | 2001-08-22 08:00 | 2001-08-23 17:00 | 77 | 7.5d | 0d | JM | 16h |
| 79 | 1.2.3.3 | Sensor data received summary page |  | 8h | 2001-08-24 08:00 | 2001-08-24 17:00 | 78 | 7.5d | 0d | JM | 8h |
| 80 | 1.2.3.4 | Hooks and disabled UI panel for future QC statistics. |  | 2h | 2001-08-27 08:00 | 2001-08-27 10:00 | 79 | 7.5d |  | JM | 2h |
| 82 | 1.3 | Integration Testing |  | 32h | 2001-09-04 11:00 | 2001-09-10 11:00 | 55, 80, 57, 75 | 0d |  | WA/JM | 32h |
| 84 | 1.4 | **Miscellaeous** |  | 2d | 2001-09-10 11:00 | 2001-09-12 11:00 | 82 | 0d |  |  | 16h |
| 86 | 1.4.1 | 7k to XTF conversion utility |  | 16h | 2001-09-10 11:00 | 2001-09-12 11:00 | 82 | 0d |  | WA | 16h |
| 88 | 1.5 | End of Phase I | milestone | 0d | 2001-09-12 11:00 | 2001-09-12 11:00 | 86, 84 | 0d |  |  |  |
| 90 | 2 | **PHASE II** |  | 0d | 2001-09-12 11:00 | 2001-09-12 11:00 | 88 | 0d |  | TBD |  |
| 92 | 2.1 | **General** |  | 0d | 2001-09-12 11:00 | 2001-09-12 11:00 |  | 0d |  |  |  |
| 94 | 2.1.1 | Serial port handler w/ time tagging. | milestone | 0d | 2001-09-12 11:00 | 2001-09-12 11:00 |  | 0d |  |  |  |
| 96 | 2.2 | **Wet End** |  | 0d | 2001-09-12 11:00 | 2001-09-12 11:00 |  | 0d |  |  |  |
| 98 | 2.2.1 | Direct logging of XTF | milestone | 0d | 2001-09-12 11:00 | 2001-09-12 11:00 |  | 0d |  |  |  |
| 99 | 2.2.2 | Optionally send Patch test messages | milestone | 0d | 2001-09-12 11:00 | 2001-09-12 11:00 |  | 0d |  |  |  |
| 100 | 2.2.3 | Replay mode for tethered testing. | milestone | 0d | 2001-09-12 11:00 | 2001-09-12 11:00 |  | 0d |  |  |  |
| 102 | 2.3 | **Dry End** |  | 0d | 2001-09-12 11:00 | 2001-09-12 11:00 |  | 0d |  |  |  |
| 104 | 2.3.1 | GUI for download/upload data. | milestone | 0d | 2001-09-12 11:00 | 2001-09-12 11:00 |  | 0d |  |  |  |
| 107 | 2.4 | **QC** |  | 0d | 2001-09-12 11:00 | 2001-09-12 11:00 |  | 0d |  |  |  |
| 109 | 2.4.1 | Collect logging statistics | milestone | 0d | 2001-09-12 11:00 | 2001-09-12 11:00 |  | 0d |  |  |  |
| 110 | 2.4.2 | Define and data oriented metrics and structures for bathy, imagery, atitude and position data. | milestone | 0d | 2001-09-12 11:00 | 2001-09-12 11:00 |  | 0d |  |  |  |
| 111 | 2.4.3 | Define and implement command set to handle configuration of QC setup/transmission modes. | milestone | 0d | 2001-09-12 11:00 | 2001-09-12 11:00 |  | 0d |  |  |  |
| 112 | 2.4.4 | Implement metric calculations for above types. | milestone | 0d | 2001-09-12 11:00 | 2001-09-12 11:00 |  | 0d |  |  |  |
| 113 | 2.4.5 | Implement optional compression and transmission of sample imagery over acoustic modem. | milestone | 0d | 2001-09-12 11:00 | 2001-09-12 11:00 |  | 0d |  |  |  |
| 114 | 2.4.6 | Implement optional transmission of summary staticstics over acoustic modem. | milestone | 0d | 2001-09-12 11:00 | 2001-09-12 11:00 |  | 0d |  |  |  |
