# Project Schedule Phase 1 and 2

Schedule from MS Project, 2001-08-01 to 2001-09-26, A marks actual dates.

## Calendars

- Standard: Mon-Fri 08:00-12:00, 13:00-17:00; Sat-Sun off. Exceptions (off unless hours are given): 2001-09-03.

## Resources

| Resource |
| --- |
| WA |
| JM |
| WA/JM |
| TBD |
| End of Phase I |
| JM/WA |

## Schedule

| ID | WBS | Task | Duration | Start | Finish | Predecessors | Complete | Remaining | Baseline start | Baseline finish | Baseline duration | Total slack | Free slack | Constraint | Resources | Work | Actual work |
| --- | --- | --- | --- | --- | --- | --- | --- | --- | --- | --- | --- | --- | --- | --- | --- | --- | --- |
| 1 | 1 | **PHASE I** | 39.75d | 2001-08-01 08:00 A | 2001-09-26 15:00 |  | 14% | 34.36d | 2001-08-01 08:00 | 2001-09-26 15:00 | 39.75d | 0d |  | start no earlier than 2001-08-01 08:00 |  | 584h | 74.6h |
| 3 | 1.1 | **Project Planning and Specification** | 2.88d | 2001-08-01 08:00 A | 2001-08-03 16:00 |  | 70% | 0.85d | 2001-08-01 08:00 | 2001-08-03 16:00 | 2.88d | 2d | 0d |  |  | 23h | 16.2h |
| 5 | 1.1.1 | Develop project schedule and task breakdown | 12h | 2001-08-01 08:00 A | 2001-08-02 12:00 A |  | 100% |  | 2001-08-01 08:00 | 2001-08-02 12:00 | 12h |  |  |  | WA | 12h | 12h |
| 6 | 1.1.2 | Define 7k records for EdgeTech SSS, SBP and sundry sensors | 4h | 2001-08-02 13:00 A | 2001-08-02 17:00 | 5 | 80% | 0.8h | 2001-08-02 13:00 | 2001-08-02 17:00 | 4h | 2.02d | 0d |  | WA | 4h | 3.2h |
| 7 | 1.1.3 | Define 7k records for command and control ASCII protocol. | 6h | 2001-08-03 08:00 | 2001-08-03 15:00 | 6 |  |  | 2001-08-03 08:00 | 2001-08-03 15:00 | 6h | 2.02d |  |  | WA | 6h |  |
| 8 | 1.1.4 | Reserve 7k records for Phase II QC needs. | 1h | 2001-08-03 15:00 A | 2001-08-03 16:00 A | 7 | 100% |  | 2001-08-03 15:00 | 2001-08-03 16:00 | 1h |  |  |  | WA | 1h | 1h |
| 10 | 1.2 | **Wet End** | 30.12d | 2001-08-03 16:00 A | 2001-09-17 17:00 | 3 | 7% | 28.12d | 2001-08-03 16:00 | 2001-09-17 17:00 | 30.12d | 0d |  |  |  | 241h | 16h |
| 12 | 1.2.1 | **General** | 9.75d | 2001-08-03 16:00 A | 2001-08-17 14:00 | 3 | 18% | 8d | 2001-08-03 16:00 | 2001-08-17 14:00 | 9.75d | 0.25d | 0d |  |  | 78h | 14h |
| 14 | 1.2.1.1 | Socket support classes. | 8h | 2001-08-03 16:00 A | 2001-08-06 16:00 | 8 | 75% | 2h | 2001-08-03 16:00 | 2001-08-06 16:00 | 8h | 3.75d | 0d |  | WA | 8h | 6h |
| 15 | 1.2.1.2 | General re-structure (polled acquisition cycle, socket exchange and command handler). | 8h | 2001-08-06 16:00 A | 2001-08-07 16:00 | 14 | 50% | 4h | 2001-08-06 16:00 | 2001-08-07 16:00 | 8h | 3.25d | 0d |  | WA | 8h | 4h |
| 16 | 1.2.1.3 | Integrate new sensor list (DLL registration). | 2h | 2001-08-07 16:00 | 2001-08-08 09:00 | 15 |  |  | 2001-08-07 16:00 | 2001-08-08 09:00 | 2h | 0.75d | 0d |  | WA | 2h |  |
| 17 | 1.2.1.4 | 7k protocol, disk I/0 and socket framing API (DLL). | 40h | 2001-08-08 09:00 A | 2001-08-15 09:00 | 16 | 10% | 36h | 2001-08-08 09:00 | 2001-08-15 09:00 | 40h | 0.25d | 0d |  | WA | 40h | 4h |
| 18 | 1.2.1.5 | Hi-Res timing support and UTC conversion API | 8h | 2001-08-15 09:00 | 2001-08-16 09:00 | 17 |  |  | 2001-08-15 09:00 | 2001-08-16 09:00 | 8h | 27.12d | 0d |  | WA | 8h |  |
| 19 | 1.2.1.6 | Command and control protocol API. | 8h | 2001-08-16 09:00 | 2001-08-17 09:00 | 18 |  |  | 2001-08-16 09:00 | 2001-08-17 09:00 | 8h | 27.12d | 0d |  | WA | 8h |  |
| 20 | 1.2.1.7 | Testing | 4h | 2001-08-17 09:00 | 2001-08-17 14:00 | 19 |  |  | 2001-08-17 09:00 | 2001-08-17 14:00 | 4h | 27.12d |  |  | WA | 4h |  |
| 22 | 1.2.2 | **EdgeTech Integration** | 7.25d | 2001-08-17 14:00 A | 2001-08-28 16:00 | 12 | 3% | 7d | 2001-08-17 14:00 | 2001-08-28 16:00 | 7.25d | 0d |  |  |  | 58h | 2h |
| 24 | 1.2.2.1 | Create DLL and framework. | 2h | 2001-08-17 14:00 A | 2001-08-17 16:00 A | 20 | 100% |  | 2001-08-17 14:00 | 2001-08-17 16:00 | 2h |  |  |  | WA | 2h | 2h |
| 25 | 1.2.2.2 | Message handler and socket reciever threads | 8h | 2001-08-17 16:00 | 2001-08-20 16:00 | 24 |  |  | 2001-08-17 16:00 | 2001-08-20 16:00 | 8h | 0d |  |  | WA | 8h |  |
| 26 | 1.2.2.3 | Command and cotrol framework. | 8h | 2001-08-20 16:00 | 2001-08-21 16:00 | 25 |  |  | 2001-08-20 16:00 | 2001-08-21 16:00 | 8h | 0d |  |  | WA | 8h |  |
| 27 | 1.2.2.4 | Data collection framework. | 8h | 2001-08-21 16:00 | 2001-08-22 16:00 | 26 |  |  | 2001-08-21 16:00 | 2001-08-22 16:00 | 8h | 0d |  |  | WA | 8h |  |
| 28 | 1.2.2.5 | Ping/channel sequencer. | 16h | 2001-08-22 16:00 | 2001-08-24 16:00 | 27 |  |  | 2001-08-22 16:00 | 2001-08-24 16:00 | 16h | 0d |  |  | WA | 16h |  |
| 29 | 1.2.2.6 | Sonar configuration save / restore settings. | 4h | 2001-08-24 16:00 | 2001-08-27 11:00 | 28 |  |  | 2001-08-24 16:00 | 2001-08-27 11:00 | 4h | 0d |  |  | WA | 4h |  |
| 30 | 1.2.2.7 | Sonar command set for remote and startup control. | 4h | 2001-08-27 11:00 | 2001-08-27 16:00 | 29 |  |  | 2001-08-27 11:00 | 2001-08-27 16:00 | 4h | 0d |  |  | WA | 4h |  |
| 31 | 1.2.2.8 | Synchronize FS-AS and payload controller clocks. | 4h | 2001-08-27 16:00 | 2001-08-28 11:00 | 30 |  |  | 2001-08-27 16:00 | 2001-08-28 11:00 | 4h | 0d |  |  | WA | 4h |  |
| 32 | 1.2.2.9 | Testing. | 4h | 2001-08-28 11:00 | 2001-08-28 16:00 | 31 |  |  | 2001-08-28 11:00 | 2001-08-28 16:00 | 4h | 0d |  |  | WA | 4h |  |

| ID | WBS | Task | Duration | Start | Finish | Predecessors | Complete | Remaining | Baseline start | Baseline finish | Baseline duration | Total slack | Free slack | Resources | Work | Actual work |
| --- | --- | --- | --- | --- | --- | --- | --- | --- | --- | --- | --- | --- | --- | --- | --- | --- |
| 34 | 1.2.3 | **Logging** | 2.12d | 2001-08-28 16:00 | 2001-08-30 17:00 | 22 |  |  | 2001-08-28 16:00 | 2001-08-30 17:00 | 2.12d | 0d |  |  | 17h |  |
| 36 | 1.2.3.1 | Record sequencing and logging support class(es). | 6h | 2001-08-28 16:00 | 2001-08-29 14:00 | 32 |  |  | 2001-08-28 16:00 | 2001-08-29 14:00 | 6h | 0d |  | WA | 6h |  |
| 37 | 1.2.3.2 | Integrate 7k logging API. | 4h | 2001-08-29 14:00 | 2001-08-30 09:00 | 36 |  |  | 2001-08-29 14:00 | 2001-08-30 09:00 | 4h | 0d |  | WA | 4h |  |
| 38 | 1.2.3.3 | Auto change of file names on file size and named logging based on time. | 2h | 2001-08-30 09:00 | 2001-08-30 11:00 | 37 |  |  | 2001-08-30 09:00 | 2001-08-30 11:00 | 2h | 0d |  | WA | 2h |  |
| 39 | 1.2.3.4 | Periodically flush logging buffers (minimize potential data loss in event of system crash). | 1h | 2001-08-30 11:00 | 2001-08-30 12:00 | 38 |  |  | 2001-08-30 11:00 | 2001-08-30 12:00 | 1h | 0d |  | WA | 1h |  |
| 40 | 1.2.3.5 | Testing | 4h | 2001-08-30 13:00 | 2001-08-30 17:00 | 39 |  |  | 2001-08-30 13:00 | 2001-08-30 17:00 | 4h | 0d |  | WA | 4h |  |
| 42 | 1.2.4 | **Payload Controller** | 9d | 2001-08-31 08:00 | 2001-09-13 17:00 | 34 |  |  | 2001-08-31 08:00 | 2001-09-13 17:00 | 9d | 0d |  |  | 72h |  |
| 44 | 1.2.4.1 | Rework message handler to be driven by 7k protocol | 16h | 2001-08-31 08:00 | 2001-09-04 17:00 | 40 |  |  | 2001-08-31 08:00 | 2001-09-04 17:00 | 16h | 0d |  | WA | 16h |  |
| 45 | 1.2.4.2 | Integrate 7k API for command logging | 4h | 2001-09-05 08:00 | 2001-09-05 12:00 | 44 |  |  | 2001-09-05 08:00 | 2001-09-05 12:00 | 4h | 0d |  | WA | 4h |  |
| 46 | 1.2.4.3 | Expand saved and restored parameter list (includes sensor state). | 4h | 2001-09-05 13:00 | 2001-09-05 17:00 | 45 |  |  | 2001-09-05 13:00 | 2001-09-05 17:00 | 4h | 0d |  | WA | 4h |  |
| 47 | 1.2.4.4 | Alarm relays ??? | 8h | 2001-09-06 08:00 | 2001-09-06 17:00 | 46 |  |  | 2001-09-06 08:00 | 2001-09-06 17:00 | 8h | 0d |  | WA | 8h |  |
| 48 | 1.2.4.5 | Sonar trigger pulse controller | 8h | 2001-09-07 08:00 | 2001-09-07 17:00 | 47 |  |  | 2001-09-07 08:00 | 2001-09-07 17:00 | 8h | 0d |  | WA | 8h |  |
| 49 | 1.2.4.6 | 1PPS controller for time sync | 8h | 2001-09-10 08:00 | 2001-09-10 17:00 | 48 |  |  | 2001-09-10 08:00 | 2001-09-10 17:00 | 8h | 0d |  | WA | 8h |  |
| 50 | 1.2.4.7 | UTC time synchronization. | 4h | 2001-09-11 08:00 | 2001-09-11 12:00 | 49 |  |  | 2001-09-11 08:00 | 2001-09-11 12:00 | 4h | 0d |  | WA | 4h |  |
| 51 | 1.2.4.8 | Supervise new sensors. | 8h | 2001-09-11 13:00 | 2001-09-12 12:00 | 50 |  |  | 2001-09-11 13:00 | 2001-09-12 12:00 | 8h | 0d |  | WA | 8h |  |
| 52 | 1.2.4.9 | Transmit status and summary information (includes logging statistics). | 8h | 2001-09-12 13:00 | 2001-09-13 12:00 | 51 |  |  | 2001-09-12 13:00 | 2001-09-13 12:00 | 8h | 0d |  | WA | 8h |  |
| 53 | 1.2.4.10 | Testing | 4h | 2001-09-13 13:00 | 2001-09-13 17:00 | 52 |  |  | 2001-09-13 13:00 | 2001-09-13 17:00 | 4h | 0d |  | WA | 4h |  |
| 55 | 1.2.5 | **Vehicle Parameters** | 1.5d | 2001-09-14 08:00 | 2001-09-17 12:00 | 42 |  |  | 2001-09-14 08:00 | 2001-09-17 12:00 | 1.5d | 0d |  |  | 12h |  |
| 57 | 1.2.5.1 | Create DLL and framework for reciept of heading, attitude and position input. | 8h | 2001-09-14 08:00 | 2001-09-14 17:00 | 53 |  |  | 2001-09-14 08:00 | 2001-09-14 17:00 | 8h | 0d |  | WA | 8h |  |
| 58 | 1.2.5.2 | Integrate 7k logging API | 2h | 2001-09-17 08:00 | 2001-09-17 10:00 | 57 |  |  | 2001-09-17 08:00 | 2001-09-17 10:00 | 2h | 0d |  | WA | 2h |  |
| 59 | 1.2.5.3 | Testing. | 2h | 2001-09-17 10:00 | 2001-09-17 12:00 | 58 |  |  | 2001-09-17 10:00 | 2001-09-17 12:00 | 2h | 0d |  | WA | 2h |  |
| 61 | 1.2.6 | **Miscellaneous** | 0.5d | 2001-09-17 13:00 | 2001-09-17 17:00 | 55 |  |  | 2001-09-17 13:00 | 2001-09-17 17:00 | 0.5d | 0d |  |  | 4h |  |
| 63 | 1.2.6.1 | Per channel emulation support (I.e., test patterns). | 4h | 2001-09-17 13:00 | 2001-09-17 17:00 | 59 |  |  | 2001-09-17 13:00 | 2001-09-17 17:00 | 4h | 0d |  | WA | 4h |  |
| 65 | 1.3 | **Dry End** | 27.75d | 2001-08-01 08:00 A | 2001-09-10 15:00 |  | 19% | 22.45d | 2001-08-01 08:00 | 2001-09-10 15:00 | 27.75d | 4.25d |  |  | 222h | 42.4h |
| 67 | 1.3.1 | **General** | 9d | 2001-08-01 08:00 A | 2001-08-13 17:00 |  | 36% | 5.75d | 2001-08-01 08:00 | 2001-08-13 17:00 | 9d | 1.5d | 0d |  | 72h | 26h |
| 69 | 1.3.1.1 | Re-structure (or create new) framework | 40h | 2001-08-01 08:00 A | 2001-08-07 17:00 |  | 65% | 14h | 2001-08-01 08:00 | 2001-08-07 17:00 | 40h | 1.5d | 0d | JM | 40h | 26h |
| 70 | 1.3.1.2 | Per sensor setup and control page | 16h | 2001-08-08 08:00 | 2001-08-09 17:00 | 69 |  |  | 2001-08-08 08:00 | 2001-08-09 17:00 | 16h | 5.5d | 0d | JM | 16h |  |
| 71 | 1.3.1.3 | Message handler object and integration of 7k protocol/socket API. | 16h | 2001-08-10 08:00 | 2001-08-13 17:00 | 70 |  |  | 2001-08-10 08:00 | 2001-08-13 17:00 | 16h | 5.5d | 0d | JM | 16h |  |

| ID | WBS | Task | Type | Duration | Start | Finish | Predecessors | Complete | Remaining | Baseline start | Baseline finish | Baseline duration | Total slack | Free slack | Resources | Work | Actual work |
| --- | --- | --- | --- | --- | --- | --- | --- | --- | --- | --- | --- | --- | --- | --- | --- | --- | --- |
| 73 | 1.3.2 | **GUI's for data viewing (Tethered mode or offline viewer (file replay)).** |  | 13d | 2001-08-14 08:00 A | 2001-08-30 17:00 | 67 | 16% | 10.95d | 2001-08-14 08:00 | 2001-08-30 17:00 | 13d | 5.5d | 0d |  | 104h | 16.4h |
| 75 | 1.3.2.1 | Infrustructure for file or socket replay of 7k records (code re-use from wet end). |  | 8h | 2001-08-14 08:00 | 2001-08-14 17:00 | 71 |  |  | 2001-08-14 08:00 | 2001-08-14 17:00 | 8h | 5.5d | 0d | JM | 8h |  |
| 76 | 1.3.2.2 | Integrate 7k command protocol API |  | 4h | 2001-08-15 08:00 | 2001-08-15 12:00 | 75 |  |  | 2001-08-15 08:00 | 2001-08-15 12:00 | 4h | 5.5d | 0d | JM | 4h |  |
| 77 | 1.3.2.3 | Generic waterfall display. |  | 40h | 2001-08-15 13:00 A | 2001-08-22 12:00 | 76 | 25% | 30h | 2001-08-15 13:00 | 2001-08-22 12:00 | 40h | 6.3d | 0d | JM | 40h | 10h |
| 78 | 1.3.2.4 | Waterfall (2 channel vertical) for SSS data. |  | 4h | 2001-08-22 13:00 | 2001-08-22 17:00 | 77 |  |  | 2001-08-22 13:00 | 2001-08-22 17:00 | 4h | 5.5d | 0d | JM | 4h |  |
| 79 | 1.3.2.5 | Waterfall (1 channel horizontal) for SBP data |  | 4h | 2001-08-23 08:00 | 2001-08-23 12:00 | 78 |  |  | 2001-08-23 08:00 | 2001-08-23 12:00 | 4h | 5.5d | 0d | JM | 4h |  |
| 80 | 1.3.2.6 | Generic time series plot graphic |  | 16h | 2001-08-23 13:00 A | 2001-08-27 12:00 | 79 | 40% | 9.6h | 2001-08-23 13:00 | 2001-08-27 12:00 | 16h | 5.5d | 0d | JM | 16h | 6.4h |
| 81 | 1.3.2.7 | Time series plot for altitude and heading |  | 4h | 2001-08-27 13:00 | 2001-08-27 17:00 | 80 |  |  | 2001-08-27 13:00 | 2001-08-27 17:00 | 4h | 5.5d | 0d | JM | 4h |  |
| 82 | 1.3.2.8 | Tables of position updates. |  | 16h | 2001-08-28 08:00 | 2001-08-29 17:00 | 81 |  |  | 2001-08-28 08:00 | 2001-08-29 17:00 | 16h | 5.5d | 0d | JM | 16h |  |
| 83 | 1.3.2.9 | Summary display for ping / time data |  | 8h | 2001-08-30 08:00 | 2001-08-30 17:00 | 82 |  |  | 2001-08-30 08:00 | 2001-08-30 17:00 | 8h | 5.5d | 0d | JM | 8h |  |
| 85 | 1.3.3 | **GUIs for payload controller** |  | 5.75d | 2001-08-31 08:00 | 2001-09-10 15:00 | 73 |  |  | 2001-08-31 08:00 | 2001-09-10 15:00 | 5.75d | 4.25d | 0d |  | 46h |  |
| 87 | 1.3.3.1 | Setup, control and status review of sensors (sensor specific). |  | 20h | 2001-08-31 08:00 | 2001-09-05 12:00 | 83 |  |  | 2001-08-31 08:00 | 2001-09-05 12:00 | 20h | 5.5d | 0d | JM | 20h |  |
| 88 | 1.3.3.2 | GUI for setup and synchronization scheme. |  | 16h | 2001-09-05 13:00 | 2001-09-07 12:00 | 87 |  |  | 2001-09-05 13:00 | 2001-09-07 12:00 | 16h | 5.5d | 0d | JM | 16h |  |
| 89 | 1.3.3.3 | Sensor data received summary page |  | 8h | 2001-09-07 13:00 | 2001-09-10 12:00 | 88 |  |  | 2001-09-07 13:00 | 2001-09-10 12:00 | 8h | 5.5d | 0d | JM | 8h |  |
| 90 | 1.3.3.4 | Hooks and disabled UI panel for future QC statistics. |  | 2h | 2001-09-10 13:00 | 2001-09-10 15:00 | 89 |  |  | 2001-09-10 13:00 | 2001-09-10 15:00 | 2h | 5.5d | 0d | JM | 2h |  |
| 92 | 1.4 | **Installation configuration** |  | 1d | 2001-09-10 15:00 | 2001-09-11 15:00 | 85 |  |  | 2001-09-10 15:00 | 2001-09-11 15:00 | 1d | 4.25d |  |  | 8h |  |
| 93 | 1.4.1 | Generate install scripts |  | 4h | 2001-09-10 15:00 | 2001-09-11 10:00 | 90 |  |  | 2001-09-10 15:00 | 2001-09-11 10:00 | 4h | 5.5d | 0d | JM | 4h |  |
| 94 | 1.4.2 | Test installed version |  | 4h | 2001-09-11 10:00 | 2001-09-11 15:00 | 93 |  |  | 2001-09-11 10:00 | 2001-09-11 15:00 | 4h | 5.5d |  | JM | 4h |  |
| 96 | 1.5 | **Integration testing** |  | 4.75d | 2001-09-18 08:00 | 2001-09-24 15:00 | 61, 92 |  |  | 2001-09-18 08:00 | 2001-09-24 15:00 | 4.75d | 0d |  |  | 74h |  |
| 97 | 1.5.1 | Setup hardware |  | 4h | 2001-09-18 08:00 | 2001-09-18 12:00 | 63, 94 |  |  | 2001-09-18 08:00 | 2001-09-18 12:00 | 4h | 0d |  | WA | 4h |  |
| 98 | 1.5.2 | Configure software and tools |  | 2h | 2001-09-18 08:00 | 2001-09-18 10:00 | 63 |  |  | 2001-09-18 08:00 | 2001-09-18 10:00 | 2h | 0.25d |  | JM | 2h |  |
| 99 | 1.5.3 | Testing and debugging |  | 34h | 2001-09-18 13:00 | 2001-09-24 15:00 | 97, 98 |  |  | 2001-09-18 13:00 | 2001-09-24 15:00 | 34h | 0d |  | WA; JM | 68h |  |
| 101 | 1.6 | Initial Release | milestone | 0d | 2001-09-24 15:00 | 2001-09-24 15:00 | 96 |  |  | 2001-09-24 15:00 | 2001-09-24 15:00 | 0d | 2d |  |  |  |  |
| 103 | 1.7 | **Miscellaeous** |  | 2d | 2001-09-24 15:00 | 2001-09-26 15:00 | 96 |  |  | 2001-09-24 15:00 | 2001-09-26 15:00 | 2d | 0d |  |  | 16h |  |
| 105 | 1.7.1 | 7k to XTF conversion utility |  | 16h | 2001-09-24 15:00 | 2001-09-26 15:00 | 99 |  |  | 2001-09-24 15:00 | 2001-09-26 15:00 | 16h | 0d |  | WA | 16h |  |
| 107 | 2 | End of Phase I | milestone | 0d | 2001-09-26 15:00 | 2001-09-26 15:00 | 103 |  |  | 2001-09-26 15:00 | 2001-09-26 15:00 | 0d | 0d |  |  |  |  |

| ID | WBS | Task | Type | Duration | Start | Finish | Predecessors | Baseline start | Baseline finish | Baseline duration | Total slack |
| --- | --- | --- | --- | --- | --- | --- | --- | --- | --- | --- | --- |
| 109 | 3 | **PHASE II** |  | 0d | 2001-09-26 15:00 | 2001-09-26 15:00 | 1 | 2001-09-26 15:00 | 2001-09-26 15:00 | 0d | 0d |
| 111 | 3.1 | **General** |  | 0d | 2001-09-26 15:00 | 2001-09-26 15:00 |  | 2001-09-26 15:00 | 2001-09-26 15:00 | 0d | 0d |
| 113 | 3.1.1 | Serial port handler w/ time tagging. | milestone | 0d | 2001-09-26 15:00 | 2001-09-26 15:00 |  | 2001-09-26 15:00 | 2001-09-26 15:00 | 0d | 0d |
| 115 | 3.2 | **Wet End** |  | 0d | 2001-09-26 15:00 | 2001-09-26 15:00 |  | 2001-09-26 15:00 | 2001-09-26 15:00 | 0d | 0d |
| 117 | 3.2.1 | Direct logging of XTF | milestone | 0d | 2001-09-26 15:00 | 2001-09-26 15:00 |  | 2001-09-26 15:00 | 2001-09-26 15:00 | 0d | 0d |
| 118 | 3.2.2 | Optionally send Patch test messages | milestone | 0d | 2001-09-26 15:00 | 2001-09-26 15:00 |  | 2001-09-26 15:00 | 2001-09-26 15:00 | 0d | 0d |
| 119 | 3.2.3 | Replay mode for tethered testing. | milestone | 0d | 2001-09-26 15:00 | 2001-09-26 15:00 |  | 2001-09-26 15:00 | 2001-09-26 15:00 | 0d | 0d |
| 120 | 3.2.4 | Wavelet compression API. | milestone | 0d | 2001-09-26 15:00 | 2001-09-26 15:00 |  | 2001-09-26 15:00 | 2001-09-26 15:00 | 0d | 0d |
| 121 | 3.2.5 | Format and transmit compressed imagery. | milestone | 0d | 2001-09-26 15:00 | 2001-09-26 15:00 |  | 2001-09-26 15:00 | 2001-09-26 15:00 | 0d | 0d |
| 123 | 3.3 | **Dry End** |  | 0d | 2001-09-26 15:00 | 2001-09-26 15:00 |  | 2001-09-26 15:00 | 2001-09-26 15:00 | 0d | 0d |
| 125 | 3.3.1 | GUI for download/upload data. | milestone | 0d | 2001-09-26 15:00 | 2001-09-26 15:00 |  | 2001-09-26 15:00 | 2001-09-26 15:00 | 0d | 0d |
| 126 | 3.3.2 | Optimize / re-work waterfall display. | milestone | 0d | 2001-09-26 15:00 | 2001-09-26 15:00 |  | 2001-09-26 15:00 | 2001-09-26 15:00 | 0d | 0d |
| 127 | 3.3.3 | Create realtime chart display. | milestone | 0d | 2001-09-26 15:00 | 2001-09-26 15:00 |  | 2001-09-26 15:00 | 2001-09-26 15:00 | 0d | 0d |
| 129 | 3.4 | **QC** |  | 0d | 2001-09-26 15:00 | 2001-09-26 15:00 |  | 2001-09-26 15:00 | 2001-09-26 15:00 | 0d | 0d |
| 131 | 3.4.1 | Collect logging statistics | milestone | 0d | 2001-09-26 15:00 | 2001-09-26 15:00 |  | 2001-09-26 15:00 | 2001-09-26 15:00 | 0d | 0d |
| 132 | 3.4.2 | Define and data oriented metrics and structures for bathy, imagery, atitude and position data. | milestone | 0d | 2001-09-26 15:00 | 2001-09-26 15:00 |  | 2001-09-26 15:00 | 2001-09-26 15:00 | 0d | 0d |
| 133 | 3.4.3 | Define and implement command set to handle configuration of QC setup/transmission modes. | milestone | 0d | 2001-09-26 15:00 | 2001-09-26 15:00 |  | 2001-09-26 15:00 | 2001-09-26 15:00 | 0d | 0d |
| 134 | 3.4.4 | Implement metric calculations for above types. | milestone | 0d | 2001-09-26 15:00 | 2001-09-26 15:00 |  | 2001-09-26 15:00 | 2001-09-26 15:00 | 0d | 0d |
| 135 | 3.4.5 | Implement optional compression and transmission of sample imagery over acoustic modem. | milestone | 0d | 2001-09-26 15:00 | 2001-09-26 15:00 |  | 2001-09-26 15:00 | 2001-09-26 15:00 | 0d | 0d |
| 136 | 3.4.6 | Implement optional transmission of summary staticstics over acoustic modem. | milestone | 0d | 2001-09-26 15:00 | 2001-09-26 15:00 |  | 2001-09-26 15:00 | 2001-09-26 15:00 | 0d | 0d |
