# Project Schedule Phase 1 and 2

Schedule from MS Project, 2001-07-30 to 2001-12-25, A marks actual dates.

## Calendars

- Standard: Mon-Fri 08:00-12:00, 13:00-17:00; Sat-Sun off. Exceptions (off unless hours are given): 2001-09-03.

## Resources

| Resource |
| --- |
| WA |
| JM |
| WA/JM |
| TBD |
| End of Phase I |
| JM/WA |

## Schedule

| ID | WBS | Task | Duration | Start | Finish | Predecessors | Complete | Remaining | Baseline start | Baseline finish | Baseline duration | Total slack | Free slack | Constraint | Resources | Work | Actual work |
| --- | --- | --- | --- | --- | --- | --- | --- | --- | --- | --- | --- | --- | --- | --- | --- | --- | --- |
| 1 | 1 | **PHASE I** | 65.75d | 2001-08-01 08:00 A | 2001-11-01 15:00 |  | 19% | 53.32d | 2001-08-01 08:00 | 2001-11-01 15:00 | 65.75d | 0d |  | start no earlier than 2001-08-01 08:00 |  | 793h | 146.9h |
| 3 | 1.1 | **Project Planning and Specification** | 8.5d | 2001-08-01 08:00 A | 2001-08-13 12:00 |  | 87% | 1.14d | 2001-08-01 08:00 | 2001-08-13 12:00 | 8.5d | 16.25d | 9.5d |  |  | 68h | 58.9h |
| 5 | 1.1.1 | Develop project schedule and task breakdown | 12h | 2001-08-01 08:00 A | 2001-08-02 12:00 A |  | 100% |  | 2001-08-01 08:00 | 2001-08-02 12:00 | 12h |  |  |  | WA | 12h | 12h |
| 6 | 1.1.2 | Reserve 7k records for Phase II QC needs. | 1h | 2001-08-02 13:00 A | 2001-08-02 14:00 A | 5 | 100% |  | 2001-08-02 13:00 | 2001-08-02 14:00 | 1h |  |  |  | WA | 1h | 1h |
| 7 | 1.1.3 | Rework 6046 SW specification | 36h | 2001-08-02 14:00 A | 2001-08-09 09:00 | 6 | 90% | 3.6h | 2001-08-02 14:00 | 2001-08-09 09:00 | 36h | 18.31d | 0d |  | WA | 36h | 32.4h |
| 8 | 1.1.4 | QC proposal | 10h | 2001-08-09 09:00 A | 2001-08-10 11:00 | 7 | 50% | 5h | 2001-08-09 09:00 | 2001-08-10 11:00 | 10h | 17.38d |  |  | WA | 10h | 5h |
| 9 | 1.1.5 | Rework project schedule | 4h | 2001-08-10 11:00 A | 2001-08-10 16:00 A | 8 | 100% |  | 2001-08-10 11:00 | 2001-08-10 16:00 | 4h |  |  |  | WA | 4h | 4h |
| 10 | 1.1.6 | Define 7k records for command and control ASCII protocol. | 3h | 2001-08-10 16:00 A | 2001-08-13 10:00 A | 9 | 100% |  | 2001-08-10 16:00 | 2001-08-13 10:00 | 3h |  |  |  | WA | 3h | 3h |
| 11 | 1.1.7 | Define 7k records for EdgeTech SSS, SBP and sundry sensors | 2h | 2001-08-13 10:00 A | 2001-08-13 12:00 | 10 | 75% | 0.5h | 2001-08-13 10:00 | 2001-08-13 12:00 | 2h | 16.25d | 9.5d |  | WA | 2h | 1.5h |
| 13 | 1.2 | **Wet End** | 40.38d | 2001-08-27 08:00 A | 2001-10-23 11:00 | 3 | 16% | 33.88d | 2001-08-27 08:00 | 2001-10-23 11:00 | 40.38d | 0.88d |  | start no earlier than 2001-08-27 08:00 |  | 323h | 52h |
| 15 | 1.2.1 | **General** | 9.75d | 2001-08-27 08:00 A | 2001-09-10 15:00 | 3 | 51% | 4.75d | 2001-08-27 08:00 | 2001-09-10 15:00 | 9.75d | 1.75d | 0d |  |  | 78h | 40h |
| 17 | 1.2.1.1 | Time, timing and general support classes. | 32h | 2001-08-27 08:00 A | 2001-08-30 17:00 | 11 | 75% | 8h | 2001-08-27 08:00 | 2001-08-30 17:00 | 32h | 3.75d | 0d |  | WA | 32h | 24h |
| 18 | 1.2.1.2 | Socket support classes. | 16h | 2001-08-31 08:00 A | 2001-09-04 17:00 | 17 | 75% | 4h | 2001-08-31 08:00 | 2001-09-04 17:00 | 16h | 2.25d | 0d |  | WA | 16h | 12h |
| 19 | 1.2.1.3 | 7k protocol, disk I/0 and socket framing API (DLL). | 16h | 2001-09-05 08:00 A | 2001-09-06 17:00 | 18 | 25% | 12h | 2001-09-05 08:00 | 2001-09-06 17:00 | 16h | 1.75d | 0d |  | WA | 16h | 4h |
| 20 | 1.2.1.4 | Command and control protocol API. | 8h | 2001-09-07 08:00 | 2001-09-07 17:00 | 19 |  |  | 2001-09-07 08:00 | 2001-09-07 17:00 | 8h | 1.75d | 0d |  | WA | 8h |  |
| 21 | 1.2.1.5 | Testing | 6h | 2001-09-10 08:00 | 2001-09-10 15:00 | 20 |  |  | 2001-09-10 08:00 | 2001-09-10 15:00 | 6h | 1.75d | 0d |  | WA | 6h |  |
| 23 | 1.2.2 | **EdgeTech Integration** | 8.25d | 2001-09-10 15:00 A | 2001-09-20 17:00 | 15 | 5% | 7.88d | 2001-09-10 15:00 | 2001-09-20 17:00 | 8.25d | 1.38d | 0d |  |  | 66h | 3h |
| 25 | 1.2.2.1 | EdgeTech simulator configuration | 2h | 2001-09-10 15:00 A | 2001-09-10 17:00 | 21 | 50% | 1h | 2001-09-10 15:00 | 2001-09-10 17:00 | 2h | 9.38d |  |  | WA | 2h | 1h |
| 26 | 1.2.2.2 | Create DLL and framework. | 2h | 2001-09-11 08:00 A | 2001-09-11 10:00 A | 25 | 100% |  | 2001-09-11 08:00 | 2001-09-11 10:00 | 2h |  |  |  | WA | 2h | 2h |
| 27 | 1.2.2.3 | Message handler and socket reciever threads | 8h | 2001-09-11 10:00 | 2001-09-12 10:00 | 26 |  |  | 2001-09-11 10:00 | 2001-09-12 10:00 | 8h | 1.38d | 0d |  | WA | 8h |  |
| 28 | 1.2.2.4 | Command and cotrol framework. | 8h | 2001-09-12 10:00 | 2001-09-13 10:00 | 27 |  |  | 2001-09-12 10:00 | 2001-09-13 10:00 | 8h | 1.38d | 0d |  | WA | 8h |  |
| 29 | 1.2.2.5 | Data collection framework. | 8h | 2001-09-13 10:00 | 2001-09-14 10:00 | 28 |  |  | 2001-09-13 10:00 | 2001-09-14 10:00 | 8h | 1.38d | 0d |  | WA | 8h |  |
| 30 | 1.2.2.6 | Ping/channel sequencer. | 16h | 2001-09-14 10:00 | 2001-09-18 10:00 | 29 |  |  | 2001-09-14 10:00 | 2001-09-18 10:00 | 16h | 1.38d | 0d |  | WA | 16h |  |
| 31 | 1.2.2.7 | Sonar configuration save / restore settings. | 6h | 2001-09-18 10:00 | 2001-09-18 17:00 | 30 |  |  | 2001-09-18 10:00 | 2001-09-18 17:00 | 6h | 1.38d | 0d |  | WA | 6h |  |
| 32 | 1.2.2.8 | Sonar command set for remote and startup control. | 4h | 2001-09-19 08:00 | 2001-09-19 12:00 | 31 |  |  | 2001-09-19 08:00 | 2001-09-19 12:00 | 4h | 1.38d | 0d |  | WA | 4h |  |
| 33 | 1.2.2.9 | Synchronize FS-AS and payload controller clocks. | 2h | 2001-09-19 13:00 | 2001-09-19 15:00 | 32 |  |  | 2001-09-19 13:00 | 2001-09-19 15:00 | 2h | 1.38d | 0d |  | WA | 2h |  |
| 34 | 1.2.2.10 | Per channel emulation support (I.e., test patterns). | 2h | 2001-09-19 15:00 | 2001-09-19 17:00 | 33 |  |  | 2001-09-19 15:00 | 2001-09-19 17:00 | 2h | 1.38d | 0d |  | WA | 2h |  |
| 35 | 1.2.2.11 | Testing. | 8h | 2001-09-20 08:00 | 2001-09-20 17:00 | 34 |  |  | 2001-09-20 08:00 | 2001-09-20 17:00 | 8h | 1.38d | 0d |  | WA | 8h |  |

| ID | WBS | Task | Duration | Start | Finish | Predecessors | Complete | Remaining | Baseline start | Baseline finish | Baseline duration | Total slack | Free slack | Resources | Work | Actual work |
| --- | --- | --- | --- | --- | --- | --- | --- | --- | --- | --- | --- | --- | --- | --- | --- | --- |
| 37 | 1.2.3 | **Payload Controller** | 22.38d | 2001-09-21 08:00 A | 2001-10-23 11:00 | 23 | 5% | 21.25d | 2001-09-21 08:00 | 2001-10-23 11:00 | 22.38d | 0.88d |  |  | 179h | 9h |
| 39 | 1.2.3.1 | **General** | 8d | 2001-09-21 08:00 A | 2001-10-02 17:00 |  | 6% | 7.5d | 2001-09-21 08:00 | 2001-10-02 17:00 | 8d | 1.5d |  |  | 64h | 4h |
| 41 | 1.2.3.1.1 | Service restructure (polled acquisition cycle, socket exchange, command handler, infrustruture). | 16h | 2001-09-21 08:00 A | 2001-09-24 17:00 | 35 | 25% | 12h | 2001-09-21 08:00 | 2001-09-24 17:00 | 16h | 1.5d | 0d | WA | 16h | 4h |
| 42 | 1.2.3.1.2 | Integrate new sensor list (DLL registration). | 4h | 2001-09-25 08:00 | 2001-09-25 12:00 | 41 |  |  | 2001-09-25 08:00 | 2001-09-25 12:00 | 4h | 0.88d | 0d | WA | 4h |  |
| 43 | 1.2.3.1.3 | Rework message handler to be driven by 7k protocol | 16h | 2001-09-25 13:00 | 2001-09-27 12:00 | 42 |  |  | 2001-09-25 13:00 | 2001-09-27 12:00 | 16h | 0.88d | 0d | WA | 16h |  |
| 44 | 1.2.3.1.4 | Expand saved and restored parameter list (includes sensor state). | 4h | 2001-09-27 13:00 | 2001-09-27 17:00 | 43 |  |  | 2001-09-27 13:00 | 2001-09-27 17:00 | 4h | 0.88d | 0d | WA | 4h |  |
| 45 | 1.2.3.1.5 | UTC time synchronization support. | 4h | 2001-09-28 08:00 | 2001-09-28 12:00 | 44 |  |  | 2001-09-28 08:00 | 2001-09-28 12:00 | 4h | 0.88d | 0d | WA | 4h |  |
| 46 | 1.2.3.1.6 | Supervise new sensors. | 8h | 2001-09-28 13:00 | 2001-10-01 12:00 | 45 |  |  | 2001-09-28 13:00 | 2001-10-01 12:00 | 8h | 0.88d | 0d | WA | 8h |  |
| 47 | 1.2.3.1.7 | Command routing | 4h | 2001-10-01 13:00 | 2001-10-01 17:00 | 46 |  |  | 2001-10-01 13:00 | 2001-10-01 17:00 | 4h | 0.88d | 0d | WA | 4h |  |
| 48 | 1.2.3.1.8 | Testing | 8h | 2001-10-02 08:00 | 2001-10-02 17:00 | 47 |  |  | 2001-10-02 08:00 | 2001-10-02 17:00 | 8h | 0.88d | 0d | WA | 8h |  |
| 50 | 1.2.3.2 | **Logging** | 2.88d | 2001-10-03 08:00 | 2001-10-05 16:00 |  |  |  | 2001-10-03 08:00 | 2001-10-05 16:00 | 2.88d | 1.5d |  |  | 23h |  |
| 52 | 1.2.3.2.1 | Record sequencing and logging support class(es). | 8h | 2001-10-03 08:00 | 2001-10-03 17:00 | 48 |  |  | 2001-10-03 08:00 | 2001-10-03 17:00 | 8h | 0.88d | 0d | WA | 8h |  |
| 53 | 1.2.3.2.2 | Integrate 7k logging API. | 4h | 2001-10-04 08:00 | 2001-10-04 12:00 | 52 |  |  | 2001-10-04 08:00 | 2001-10-04 12:00 | 4h | 0.88d | 0d | WA | 4h |  |
| 54 | 1.2.3.2.3 | Auto change of file names on file size and named logging based on time. | 2h | 2001-10-04 13:00 | 2001-10-04 15:00 | 53 |  |  | 2001-10-04 13:00 | 2001-10-04 15:00 | 2h | 0.88d | 0d | WA | 2h |  |
| 55 | 1.2.3.2.4 | Periodically flush logging buffers (minimize potential data loss in event of system crash). | 1h | 2001-10-04 15:00 | 2001-10-04 16:00 | 54 |  |  | 2001-10-04 15:00 | 2001-10-04 16:00 | 1h | 0.88d | 0d | WA | 1h |  |
| 56 | 1.2.3.2.5 | Testing | 8h | 2001-10-04 16:00 | 2001-10-05 16:00 | 55 |  |  | 2001-10-04 16:00 | 2001-10-05 16:00 | 8h | 0.88d | 0d | WA | 8h |  |
| 58 | 1.2.3.3 | **Survey Event Log** | 1.75d | 2001-10-05 16:00 A | 2001-10-09 14:00 |  | 36% | 1.12d | 2001-10-05 16:00 | 2001-10-09 14:00 | 1.75d | 0.88d |  |  | 14h | 5h |
| 59 | 1.2.3.3.1 | Re-work infrustructure | 10h | 2001-10-05 16:00 A | 2001-10-09 09:00 | 56 | 50% | 5h | 2001-10-05 16:00 | 2001-10-09 09:00 | 10h | 0.88d | 0d | WA | 10h | 5h |
| 60 | 1.2.3.3.2 | Testing | 4h | 2001-10-09 09:00 | 2001-10-09 14:00 | 59 |  |  | 2001-10-09 09:00 | 2001-10-09 14:00 | 4h | 0.88d | 0d | WA | 4h |  |
| 62 | 1.2.3.4 | **Alarm and Status Monitoring** | 3.25d | 2001-10-09 14:00 | 2001-10-12 16:00 |  |  |  | 2001-10-09 14:00 | 2001-10-12 16:00 | 3.25d | 0.88d |  |  | 26h |  |
| 63 | 1.2.3.4.1 | Infrastructure | 8h | 2001-10-09 14:00 | 2001-10-10 14:00 | 60 |  |  | 2001-10-09 14:00 | 2001-10-10 14:00 | 8h | 0.88d | 0d | WA | 8h |  |
| 64 | 1.2.3.4.2 | Status monitoring | 8h | 2001-10-10 14:00 | 2001-10-11 14:00 | 63 |  |  | 2001-10-10 14:00 | 2001-10-11 14:00 | 8h | 0.88d | 0d | WA | 8h |  |
| 65 | 1.2.3.4.3 | Messaging to client(s) and Survey Event Log | 6h | 2001-10-11 14:00 | 2001-10-12 11:00 | 64 |  |  | 2001-10-11 14:00 | 2001-10-12 11:00 | 6h | 0.88d | 0d | WA | 6h |  |
| 66 | 1.2.3.4.4 | Testing | 4h | 2001-10-12 11:00 | 2001-10-12 16:00 | 65 |  |  | 2001-10-12 11:00 | 2001-10-12 16:00 | 4h | 0.88d | 0d | WA | 4h |  |

| ID | WBS | Task | Duration | Start | Finish | Predecessors | Complete | Remaining | Baseline start | Baseline finish | Baseline duration | Total slack | Free slack | Constraint | Resources | Work | Actual work |
| --- | --- | --- | --- | --- | --- | --- | --- | --- | --- | --- | --- | --- | --- | --- | --- | --- | --- |
| 68 | 1.2.3.5 | **Trigger Controller** | 2.5d | 2001-10-12 16:00 | 2001-10-17 11:00 |  |  |  | 2001-10-12 16:00 | 2001-10-17 11:00 | 2.5d | 0.88d |  |  |  | 20h |  |
| 69 | 1.2.3.5.1 | Interface definition | 8h | 2001-10-12 16:00 | 2001-10-15 16:00 | 66 |  |  | 2001-10-12 16:00 | 2001-10-15 16:00 | 8h | 0.88d | 0d |  | WA | 8h |  |
| 70 | 1.2.3.5.2 | Interface to payload controller. | 4h | 2001-10-15 16:00 | 2001-10-16 11:00 | 69 |  |  | 2001-10-15 16:00 | 2001-10-16 11:00 | 4h | 0.88d | 0d |  | WA | 4h |  |
| 71 | 1.2.3.5.3 | Software trigger scheme | 4h | 2001-10-16 11:00 | 2001-10-16 16:00 | 70 |  |  | 2001-10-16 11:00 | 2001-10-16 16:00 | 4h | 0.88d | 0d |  | WA | 4h |  |
| 72 | 1.2.3.5.4 | Testing | 4h | 2001-10-16 16:00 | 2001-10-17 11:00 | 71 |  |  | 2001-10-16 16:00 | 2001-10-17 11:00 | 4h | 0.88d | 0d |  | WA | 4h |  |
| 74 | 1.2.3.6 | **Vehicle Interfacing** | 4d | 2001-10-17 11:00 | 2001-10-23 11:00 |  |  |  | 2001-10-17 11:00 | 2001-10-23 11:00 | 4d | 0.88d |  |  |  | 32h |  |
| 76 | 1.2.3.6.1 | Infrastructure. | 4h | 2001-10-17 11:00 | 2001-10-17 16:00 | 72 |  |  | 2001-10-17 11:00 | 2001-10-17 16:00 | 4h | 0.88d | 0d |  | WA | 4h |  |
| 77 | 1.2.3.6.2 | Interface to Vehicle computer. | 8h | 2001-10-17 16:00 | 2001-10-18 16:00 | 76 |  |  | 2001-10-17 16:00 | 2001-10-18 16:00 | 8h | 0.88d | 0d |  | WA | 8h |  |
| 78 | 1.2.3.6.3 | Interface to CAN system | 8h | 2001-10-18 16:00 | 2001-10-19 16:00 | 77 |  |  | 2001-10-18 16:00 | 2001-10-19 16:00 | 8h | 0.88d | 0d |  | WA | 8h |  |
| 79 | 1.2.3.6.4 | Benchmark testing of 100 Hz update rates. | 4h | 2001-10-19 16:00 | 2001-10-22 11:00 | 78 |  |  | 2001-10-19 16:00 | 2001-10-22 11:00 | 4h | 0.88d | 0d |  | WA | 4h |  |
| 80 | 1.2.3.6.5 | Data formatting | 4h | 2001-10-22 11:00 | 2001-10-22 16:00 | 79 |  |  | 2001-10-22 11:00 | 2001-10-22 16:00 | 4h | 0.88d | 0d |  | WA | 4h |  |
| 81 | 1.2.3.6.6 | Testing. | 4h | 2001-10-22 16:00 | 2001-10-23 11:00 | 80 |  |  | 2001-10-22 16:00 | 2001-10-23 11:00 | 4h | 0.88d |  |  | WA | 4h |  |
| 83 | 1.3 | **Dry End** | 38.75d | 2001-08-27 08:00 A | 2001-10-19 15:00 |  | 12% | 34.25d | 2001-08-27 08:00 | 2001-10-19 15:00 | 38.75d | 0d |  | start no earlier than 2001-08-27 08:00 |  | 294h | 36h |
| 85 | 1.3.1 | **Prototyping** | 11d | 2001-08-27 08:00 A | 2001-09-11 17:00 |  | 41% | 6.5d | 2001-08-27 08:00 | 2001-09-11 17:00 | 11d | 0d |  |  |  | 88h | 36h |
| 87 | 1.3.1.1 | Waterfall display class(es) | 48h | 2001-08-27 08:00 A | 2001-09-04 17:00 |  | 75% | 12h | 2001-08-27 08:00 | 2001-09-04 17:00 | 48h | 0d |  |  | JM | 48h | 36h |
| 88 | 1.3.1.2 | Timeseries plot class(es) | 40h | 2001-09-05 08:00 | 2001-09-11 17:00 | 87 |  |  | 2001-09-05 08:00 | 2001-09-11 17:00 | 40h | 0d |  |  | JM | 40h |  |
| 90 | 1.3.2 | **Infrastructure** | 11d | 2001-09-12 08:00 | 2001-09-26 17:00 | 85 |  |  | 2001-09-12 08:00 | 2001-09-26 17:00 | 11d | 0d |  |  |  | 88h |  |
| 92 | 1.3.2.1 | Restructure framework | 40h | 2001-09-12 08:00 | 2001-09-18 17:00 | 88 |  |  | 2001-09-12 08:00 | 2001-09-18 17:00 | 40h | 0d |  |  | JM | 40h |  |
| 93 | 1.3.2.2 | Per sensor setup and control page | 16h | 2001-09-19 08:00 | 2001-09-20 17:00 | 92 |  |  | 2001-09-19 08:00 | 2001-09-20 17:00 | 16h | 0d |  |  | JM | 16h |  |
| 94 | 1.3.2.3 | Message handler object and integration of 7k protocol/socket API. | 16h | 2001-09-21 08:00 | 2001-09-24 17:00 | 93 |  |  | 2001-09-21 08:00 | 2001-09-24 17:00 | 16h | 0d |  |  | JM | 16h |  |
| 95 | 1.3.2.4 | 7k file replay mechanism and integration of 7k data replay DLL | 16h | 2001-09-25 08:00 | 2001-09-26 17:00 | 94 |  |  | 2001-09-25 08:00 | 2001-09-26 17:00 | 16h | 0d |  |  | JM | 16h |  |
| 97 | 1.3.3 | **Visualization Displays for Playback** | 12d | 2001-09-27 08:00 | 2001-10-12 17:00 | 90 |  |  | 2001-09-27 08:00 | 2001-10-12 17:00 | 12d | 0d |  |  |  | 80h |  |
| 99 | 1.3.3.1 | Integrate 7k command protocol API | 8h | 2001-09-27 08:00 | 2001-09-27 17:00 | 95 |  |  | 2001-09-27 08:00 | 2001-09-27 17:00 | 8h | 0d |  |  | JM | 8h |  |
| 100 | 1.3.3.2 | Data scaling and pre-processing | 16h | 2001-09-28 08:00 | 2001-10-01 17:00 | 99 |  |  | 2001-09-28 08:00 | 2001-10-01 17:00 | 16h | 0d |  |  | JM | 16h |  |
| 101 | 1.3.3.3 | Integrate waterfall display for SSS. | 12h | 2001-10-02 08:00 | 2001-10-03 12:00 | 100 |  |  | 2001-10-02 08:00 | 2001-10-03 12:00 | 12h | 0d |  |  | JM | 12h |  |
| 102 | 1.3.3.4 | Integrate waterfall display for SBP. | 12h | 2001-10-03 13:00 | 2001-10-04 17:00 | 101 |  |  | 2001-10-03 13:00 | 2001-10-04 17:00 | 12h | 0d |  |  | JM | 12h |  |
| 103 | 1.3.3.5 | Integrate time series plot graphics and parameter mapping. | 16h | 2001-10-05 08:00 | 2001-10-08 17:00 | 102 |  |  | 2001-10-05 08:00 | 2001-10-08 17:00 | 16h | 0d |  |  | JM | 16h |  |
| 104 | 1.3.3.6 | Tables of position updates. | 8h | 2001-10-09 08:00 | 2001-10-09 17:00 | 103 |  |  | 2001-10-09 08:00 | 2001-10-09 17:00 | 8h | 0d |  |  | JM | 8h |  |
| 105 | 1.3.3.7 | Summary display for ping / time data | 8h | 2001-10-10 08:00 | 2001-10-10 17:00 | 104 |  |  | 2001-10-10 08:00 | 2001-10-10 17:00 | 8h | 0d |  |  | JM | 8h |  |
| 106 | 1.3.3.8 | Testing | 16h | 2001-10-11 08:00 | 2001-10-12 17:00 | 105 |  |  | 2001-10-11 08:00 | 2001-10-12 17:00 | 16h | 0d |  |  |  |  |  |

| ID | WBS | Task | Type | Duration | Start | Finish | Predecessors | Baseline start | Baseline finish | Baseline duration | Total slack | Resources | Work |
| --- | --- | --- | --- | --- | --- | --- | --- | --- | --- | --- | --- | --- | --- |
| 108 | 1.3.4 | **GUIs for payload controller** |  | 4.75d | 2001-10-15 08:00 | 2001-10-19 15:00 | 97 | 2001-10-15 08:00 | 2001-10-19 15:00 | 4.75d | 0d |  | 38h |
| 110 | 1.3.4.1 | Setup, control and status review of sensors (sensor specific). |  | 20h | 2001-10-15 08:00 | 2001-10-17 12:00 | 106 | 2001-10-15 08:00 | 2001-10-17 12:00 | 20h | 0d | JM | 20h |
| 111 | 1.3.4.2 | GUI for setup and synchronization scheme. |  | 10h | 2001-10-17 13:00 | 2001-10-18 15:00 | 110 | 2001-10-17 13:00 | 2001-10-18 15:00 | 10h | 0d | JM | 10h |
| 112 | 1.3.4.3 | Sensor data received summary page |  | 8h | 2001-10-18 15:00 | 2001-10-19 15:00 | 111 | 2001-10-18 15:00 | 2001-10-19 15:00 | 8h | 0d | JM | 8h |
| 114 | 1.4 | **Installation Program** |  | 2.5d | 2001-10-19 15:00 | 2001-10-24 10:00 | 108, 83 | 2001-10-19 15:00 | 2001-10-24 10:00 | 2.5d | 0d |  | 20h |
| 116 | 1.4.1 | Generate install scripts |  | 16h | 2001-10-19 15:00 | 2001-10-23 15:00 | 112 | 2001-10-19 15:00 | 2001-10-23 15:00 | 16h | 0d | JM | 16h |
| 117 | 1.4.2 | Testing |  | 4h | 2001-10-23 15:00 | 2001-10-24 10:00 | 116 | 2001-10-23 15:00 | 2001-10-24 10:00 | 4h | 0d | JM | 4h |
| 119 | 1.5 | **Integration testing** |  | 4.5d | 2001-10-24 10:00 | 2001-10-30 15:00 | 114, 37, 13 | 2001-10-24 10:00 | 2001-10-30 15:00 | 4.5d | 0d |  | 72h |
| 121 | 1.5.1 | Setup hardware |  | 4h | 2001-10-24 10:00 | 2001-10-24 15:00 | 81 | 2001-10-24 10:00 | 2001-10-24 15:00 | 4h | 0d | WA | 4h |
| 122 | 1.5.2 | Configure software and tools |  | 4h | 2001-10-24 10:00 | 2001-10-24 15:00 | 117 | 2001-10-24 10:00 | 2001-10-24 15:00 | 4h | 0d | JM | 4h |
| 123 | 1.5.3 | Testing and debugging |  | 32h | 2001-10-24 15:00 | 2001-10-30 15:00 | 121, 122 | 2001-10-24 15:00 | 2001-10-30 15:00 | 32h | 0d | WA; JM | 64h |
| 125 | 1.6 | **Utilities** |  | 2d | 2001-10-30 15:00 | 2001-11-01 15:00 | 119 | 2001-10-30 15:00 | 2001-11-01 15:00 | 2d | 0d |  | 16h |
| 127 | 1.6.1 | 7k to XTF conversion utility |  | 16h | 2001-10-30 15:00 | 2001-11-01 15:00 | 123 | 2001-10-30 15:00 | 2001-11-01 15:00 | 16h | 0d | WA | 16h |
| 129 | 2 | **PHASE II** |  | 37.5d | 2001-11-01 15:00 | 2001-12-25 10:00 | 1, 125 | 2001-11-01 15:00 | 2001-12-25 10:00 | 37.5d | 0d |  | 304h |
| 131 | 2.1 | **Wet End** |  | 7.5d | 2001-11-01 15:00 | 2001-11-13 10:00 |  | 2001-11-01 15:00 | 2001-11-13 10:00 | 7.5d | 0d |  | 60h |
| 133 | 2.1.1 | Direct logging of XTF |  | 16h | 2001-11-01 15:00 | 2001-11-05 15:00 | 127 | 2001-11-01 15:00 | 2001-11-05 15:00 | 16h | 0d | WA | 16h |
| 134 | 2.1.2 | Data messages for realtime display |  | 16h | 2001-11-05 15:00 | 2001-11-07 15:00 | 133 | 2001-11-05 15:00 | 2001-11-07 15:00 | 16h | 0d | WA | 16h |
| 135 | 2.1.3 | Collect logging statistics |  | 4h | 2001-11-07 15:00 | 2001-11-08 10:00 | 134 | 2001-11-07 15:00 | 2001-11-08 10:00 | 4h | 0d | WA | 4h |
| 136 | 2.1.4 | Re-work Timing Controller for HW supervision |  | 24h | 2001-11-08 10:00 | 2001-11-13 10:00 | 135 | 2001-11-08 10:00 | 2001-11-13 10:00 | 24h | 0d | WA | 24h |
| 138 | 2.2 | **Dry End** |  | 0.5d | 2001-11-01 15:00 | 2001-11-02 10:00 | 119 | 2001-11-01 15:00 | 2001-11-02 10:00 | 0.5d | 37d |  | 4h |
| 140 | 2.2.1 | Realtime display integration |  | 4h | 2001-11-01 15:00 | 2001-11-02 10:00 | 123 | 2001-11-01 15:00 | 2001-11-02 10:00 | 4h | 37d | JM | 4h |
| 142 | 2.3 | **QC (TBD - Subject to proposal acceptance)** |  | 30d | 2001-11-13 10:00 | 2001-12-25 10:00 | 131 | 2001-11-13 10:00 | 2001-12-25 10:00 | 30d | 0d |  | 240h |
| 143 | 2.3.1 | TBD |  | 240h | 2001-11-13 10:00 | 2001-12-25 10:00 | 136 | 2001-11-13 10:00 | 2001-12-25 10:00 | 240h | 0d | TBD | 240h |
| 145 | 3 | Initial release | milestone | 0h | 2001-10-30 15:00 | 2001-10-30 15:00 | 119 | 2001-10-30 15:00 | 2001-10-30 15:00 | 0h | 39.5d |  |  |
| 146 | 4 | Final release | milestone | 0h | 2001-12-25 10:00 | 2001-12-25 10:00 | 129, 142, 138, 140 | 2001-12-25 10:00 | 2001-12-25 10:00 | 0h | 0d |  |  |

| ID | WBS | Task | Type | Duration | Start | Finish | Baseline start | Baseline finish | Baseline duration | Total slack |
| --- | --- | --- | --- | --- | --- | --- | --- | --- | --- | --- |
| 148 | 5 | **PHASE III (unscheduled - future work)** |  | 0d | 2001-07-30 08:00 | 2001-07-30 08:00 | 2001-07-30 08:00 | 2001-07-30 08:00 | 0d | 105.25d |
| 150 | 5.1 | **Dry End** |  | 0d | 2001-07-30 08:00 | 2001-07-30 08:00 | 2001-07-30 08:00 | 2001-07-30 08:00 | 0d | 105.25d |
| 151 | 5.1.1 | File transfer GUI and control. | milestone | 0h | 2001-07-30 08:00 | 2001-07-30 08:00 | 2001-07-30 08:00 | 2001-07-30 08:00 | 0h | 105.25d |
| 153 | 5.2 | **Wet End** |  | 0d | 2001-07-30 08:00 | 2001-07-30 08:00 | 2001-07-30 08:00 | 2001-07-30 08:00 | 0d | 105.25d |
| 155 | 5.2.1 | File transferPLC support. | milestone | 0h | 2001-07-30 08:00 | 2001-07-30 08:00 | 2001-07-30 08:00 | 2001-07-30 08:00 | 0h | 105.25d |
| 156 | 5.2.2 | Serial port handler w/ time tagging. | milestone | 0h | 2001-07-30 08:00 | 2001-07-30 08:00 | 2001-07-30 08:00 | 2001-07-30 08:00 | 0h | 105.25d |
| 157 | 5.2.3 | Optionally send Patch Test messages. | milestone | 0h | 2001-07-30 08:00 | 2001-07-30 08:00 | 2001-07-30 08:00 | 2001-07-30 08:00 | 0h | 105.25d |
| 158 | 5.2.4 | Interface to 6041. | milestone | 0h | 2001-07-30 08:00 | 2001-07-30 08:00 | 2001-07-30 08:00 | 2001-07-30 08:00 | 0h | 105.25d |
